# Состав инвестпроекта

Schedule from MS Project, 2005-07-01 to 2011-05-04.

## Calendars

- Стандартный: Mon-Fri 09:00-13:00, 14:00-18:00; Sat-Sun off. Exceptions (off unless hours are given): 2005-11-07, 2005-12-12, 2006-01-02, 2006-01-09, 2006-02-23, 2006-03-08, 2006-05-01 to 2006-05-02, 2006-05-09.

## Schedule

| ID | WBS | Task | Duration | Start | Finish | Predecessors | Total slack | Free slack |
| --- | --- | --- | --- | --- | --- | --- | --- | --- |
| 1 | 1 | **ВЫПОЛНЕНИЕ ТИПОВОГО ИНВЕСТИЦИОННОГО ПРОЕКТА** | 1515d | 2005-07-01 | 2011-05-04 |  | 0d |  |
| 2 | 1.1 | **PHYS-ABILITY STUDY** | 268d | 2005-07-01 | 2006-07-24 |  | 0d |  |
| 3 | 1.1.1 | Постановка первоначальной задачи инвестиционного проекта | 1w | 2005-07-01 | 2005-07-07 |  | 0d |  |
| 4 | 1.1.2 | Подбор вариантов строительных площадок | 1mo | 2005-07-08 | 2005-08-18 | 3 | 0d |  |
| 5 | 1.1.3 | **Экспертиза старых зданий и сооружений** | 105d | 2005-08-19 | 2006-01-18 |  | 1375d |  |
| 6 | 1.1.3.1 | Разработка техзадания на экспертизу | 15d | 2005-08-19 | 2005-09-08 | 4 | 1465d |  |
| 7 | 1.1.3.2 | Переговоры с потенциальными исполнителями | 1mo | 2005-08-19 | 2005-09-29 | 4 | 1375d | 0d |
| 8 | 1.1.3.3 | Разработка и согласование договора | 2w | 2005-09-30 | 2005-10-13 | 7 | 1375d | 0d |
| 9 | 1.1.3.4 | Подписание договора | 1w | 2005-10-14 | 2005-10-20 | 8 | 1375d | 0d |
| 10 | 1.1.3.5 | Проведение экспертизы | 2mo | 2005-10-21 | 2006-01-18 | 9 | 1375d |  |
| 11 | 1.1.4 | **Экспертиза инфраструктуры** | 75d | 2005-08-19 | 2005-12-02 |  | 1405d |  |
| 12 | 1.1.4.1 | Разработка техзадания на экспертизу | 15d | 2005-08-19 | 2005-09-08 | 4 | 1465d |  |
| 13 | 1.1.4.2 | Переговоры с потенциальными исполнителями | 1mo | 2005-08-19 | 2005-09-29 | 4 | 1405d | 0d |
| 14 | 1.1.4.3 | Разработка и согласование договора | 2w | 2005-09-30 | 2005-10-13 | 13 | 1405d | 0d |
| 15 | 1.1.4.4 | Подписание договора | 1w | 2005-10-14 | 2005-10-20 | 14 | 1405d | 0d |
| 16 | 1.1.4.5 | Проведение экспертизы | 1mo | 2005-10-21 | 2005-12-02 | 15 | 1405d |  |
| 17 | 1.1.5 | **Экспертиза существующих технологий и оборудования** | 105d | 2005-08-19 | 2006-01-18 |  | 1375d |  |
| 18 | 1.1.5.1 | Разработка техзадания на экспертизу | 15d | 2005-08-19 | 2005-09-08 | 4 | 1465d |  |
| 19 | 1.1.5.2 | Переговоры с потенциальными исполнителями | 1mo | 2005-08-19 | 2005-09-29 | 4 | 1375d | 0d |
| 20 | 1.1.5.3 | Разработка и согласование договора | 2w | 2005-09-30 | 2005-10-13 | 19 | 1375d | 0d |
| 21 | 1.1.5.4 | Подписание договора | 1w | 2005-10-14 | 2005-10-20 | 20 | 1375d | 0d |
| 22 | 1.1.5.5 | Проведение экспертизы | 2mo | 2005-10-21 | 2006-01-18 | 21 | 1375d |  |
| 23 | 1.1.6 | Составление базы данных поставщиков технологии | 3mo | 2005-08-19 | 2005-12-26 | 4 | 1390d |  |
| 24 | 1.1.7 | Составление базы данных поставщиков оборудования | 3mo | 2005-08-19 | 2005-12-26 | 4 | 570d | 0d |
| 25 | 1.1.8 | Составление базы данных проектантов | 1mo | 2005-08-19 | 2005-09-29 | 4 | 155d | 0d |
| 26 | 1.1.9 | Составлени базы данных строителей и монтажникков | 1mo | 2005-08-19 | 2005-09-29 | 4 | 1450d |  |
| 27 | 1.1.10 | Составление базы данных инжиниринговых компаний | 1mo | 2005-08-19 | 2005-09-29 | 4 | 1250d | 0d |
| 28 | 1.1.11 | Составление базы данных компаний-логистиков | 1mo | 2005-08-19 | 2005-09-29 | 4 | 1450d |  |

| ID | WBS | Task | Duration | Start | Finish | Predecessors | Total slack | Free slack |
| --- | --- | --- | --- | --- | --- | --- | --- | --- |
| 29 | 1.1.12 | **Переговоры с потенциальными подрядчиками** | 210d | 2005-08-19 | 2006-06-21 | 3 | 1247d | 0d |
| 30 | 1.1.12.1 | Переговоры с потенциальными поставщиками оборудования | 4mo | 2005-12-27 | 2006-06-21 | 24 | 1247d |  |
| 31 | 1.1.12.2 | Переговоры с инжиниринговыми компаниями | 3mo | 2005-09-30 | 2006-02-08 | 27 | 1337d |  |
| 32 | 1.1.12.3 | Переговоры с поставщиками энергоресурсов | 2mo | 2005-08-19 | 2005-11-11 | 4 | 1397d |  |
| 33 | 1.1.12.4 | Переговоры с потенциальными лигистиками и таможенными брокерами | 2mo | 2005-08-19 | 2005-11-11 | 4 | 1397d |  |
| 34 | 1.1.12.5 | Переговоры с потенциальными разработчиками НТД | 1mo | 2005-08-19 | 2005-09-29 | 4 | 1427d |  |
| 35 | 1.1.12.6 | Переговоры с потенциальными экспертами | 1mo | 2005-08-19 | 2005-09-29 | 4 | 1427d |  |
| 36 | 1.1.13 | **Проведение маркетингового исследования** | 233d | 2005-08-19 | 2006-07-24 |  | 1247d |  |
| 37 | 1.1.13.1 | Сбор информации об аналогах продукции | 2mo | 2005-08-19 | 2005-11-11 | 4 | 1420d |  |
| 38 | 1.1.13.2 | Сбор информации о производителях аналогов продукции | 2mo | 2005-08-19 | 2005-11-11 | 4 | 1390d | 0d |
| 39 | 1.1.13.3 | Подготовка маркетингового отчета | 1mo | 2005-11-14 | 2005-12-26 | 38 | 1390d |  |
| 40 | 1.1.13.4 | ТЗ инвестиционного проекта. 1-я инсталяция. | 1w | 2006-06-22 | 2006-06-28 | 29 | 1265d |  |
| 41 | 1.1.13.5 | Предварительные ТЭР для бизнесплана | 1w | 2006-06-22 | 2006-06-28 | 29 | 1247d | 0d |
| 42 | 1.1.13.6 | Бизнесплан. 1-я инсталяция | 1w | 2006-06-29 | 2006-07-05 | 41 | 1247d | 0d |
| 43 | 1.1.13.7 | Подготовка отчета по Phys-Ability Study | 1w | 2006-07-06 | 2006-07-12 | 42 | 1247d | 0d |
| 44 | 1.1.13.8 | Принятия решения об этапности (очередности) выполнения инвест.проекта | 5d | 2006-07-13 | 2006-07-19 | 43 | 1247d | 0d |
| 45 | 1.1.13.9 | Утверждения результатов Phys-Ability Stady | 3d | 2006-07-20 | 2006-07-24 | 44 | 1247d |  |
| 46 | 1.2 | **ЛИЦЕНЗИЯ НА ПРОДУКТ (ТЕХНОЛОГИЮ)** | 245d | 2005-08-19 | 2006-08-09 |  | 0d |  |
| 47 | 1.2.1 | Переговоры с потенциальными лицензиарами | 4mo | 2005-08-19 | 2006-02-08 | 4 | 0d |  |
| 48 | 1.2.2 | Выбор лицензиара | 1mo | 2006-02-09 | 2006-03-24 | 47 | 0d |  |
| 49 | 1.2.3 | **Лицензионное соглашение** | 95d | 2006-03-27 | 2006-08-09 |  | 0d |  |
| 50 | 1.2.3.1 | Переговоры с лицензиаром | 1mo | 2006-03-27 | 2006-05-10 | 48 | 0d |  |
| 51 | 1.2.3.2 | Разработка текста соглашения | 15d | 2006-05-11 | 2006-05-31 | 50 | 1285d |  |
| 52 | 1.2.3.3 | Разработка приложений к соглашению | 1mo | 2006-05-11 | 2006-06-21 | 50 | 0d |  |
| 53 | 1.2.3.4 | Переговоры с лицензиаром | 1mo | 2006-06-22 | 2006-08-02 | 52 | 0d |  |
| 54 | 1.2.3.5 | Подписание лицензионного соглашения | 1w | 2006-08-03 | 2006-08-09 | 53 | 0d |  |

| ID | WBS | Task | Duration | Start | Finish | Predecessors | Total slack | Free slack |
| --- | --- | --- | --- | --- | --- | --- | --- | --- |
| 55 | 1.3 | **ПРОЕКТИРОВАНИЕ** | 765d | 2005-09-30 | 2008-09-17 | 25 | 155d |  |
| 56 | 1.3.1 | **Исходные данные для проектирования** | 70d | 2006-08-10 | 2006-11-15 | 48 | 0d |  |
| 57 | 1.3.1.1 | Техническое задание на исходные данные | 2w | 2006-08-10 | 2006-08-23 | 54 | 0d |  |
| 58 | 1.3.1.2 | Переговоры с потенц.исполнителями ИД | 1mo | 2006-08-24 | 2006-10-04 | 57 | 0d |  |
| 59 | 1.3.1.3 | Разработка ИД | 1mo | 2006-10-05 | 2006-11-15 | 58 | 0d |  |
| 60 | 1.3.2 | ТЗ инвестиционного проекта. 2-я инсталяция. | 1w | 2006-11-16 | 2006-11-22 | 59 | 325d | 0d |
| 61 | 1.3.3 | Бизнесплан. 2-я инсталяция | 1w | 2006-11-23 | 2006-11-29 | 60 | 325d | 0d |
| 62 | 1.3.4 | **Выбор ген.проектировщика (проектировщиков)** | 90d | 2005-09-30 | 2006-02-08 | 25 | 155d |  |
| 63 | 1.3.4.1 | Переговоры с проектными организациями | 2mo | 2005-09-30 | 2005-12-26 | 25 | 155d | 0d |
| 64 | 1.3.4.2 | Принятие решение о наличии/отсутствии ген.проектировщика | 1mo | 2005-12-27 | 2006-02-08 | 63 | 155d | 0d |
| 65 | 1.3.5 | **Договоры на ген.проектирование (проектирование)** | 40d | 2006-02-09 | 2006-04-07 | 64 | 155d |  |
| 66 | 1.3.5.1 | Разработка текста договора | 1w | 2006-02-09 | 2006-02-15 | 64 | 155d | 0d |
| 67 | 1.3.5.2 | Согласование текста договора | 1mo | 2006-02-16 | 2006-03-31 | 66 | 155d | 0d |
| 68 | 1.3.5.3 | Разработка приложений к договору | 1mo | 2006-02-09 | 2006-03-24 | 64 | 1330d |  |
| 69 | 1.3.5.4 | Согласование приложений к договору | 1mo | 2006-02-16 | 2006-03-31 | 66 | 885d |  |
| 70 | 1.3.5.5 | Подписание договора | 1w | 2006-04-03 | 2006-04-07 | 67 | 155d |  |
| 71 | 1.3.6 | **Фор-проект - Basic Engineering (1-й этап проектирования)** | 150d | 2006-11-16 | 2007-06-13 | 56 | 0d |  |
| 72 | 1.3.6.1 | Выполнение фор-проекта | 3mo | 2006-11-16 | 2007-03-21 | 70 | 0d |  |
| 73 | 1.3.6.2 | Перевод Basic Engineering на русский язык | 1mo | 2007-03-22 | 2007-05-02 | 72 | 0d |  |
| 74 | 1.3.6.3 | Согласование и корректировка фор-проекта | 1mo | 2007-05-03 | 2007-06-13 | 73 | 0d |  |
| 75 | 1.3.7 | **ТЗ инвестиционного проекта. 3-я инсталяция.** | 5d | 2007-06-14 | 2007-06-20 |  | 935d |  |
| 76 | 1.3.7.1 | Список приложений к ТЗ инвестпроекта | 1w | 2007-06-14 | 2007-06-20 | 74 | 935d | 0d |
| 77 | 1.3.8 | Бизнесплан. 3-я инсталяция | 1w | 2007-06-21 | 2007-06-27 | 76 | 935d | 0d |
| 78 | 1.3.9 | **Рабочий проект с утверждаемой частью (2-й этап проектирования)** | 185d | 2007-06-14 | 2008-02-27 | 71 | 0d |  |
| 79 | 1.3.9.1 | Выполнение рабочего проекта | 4mo | 2007-06-14 | 2007-11-28 | 71 | 0d |  |
| 80 | 1.3.9.2 | Согласование и корректировка рабочего проекта | 2mo | 2007-11-29 | 2008-02-20 | 79 | 0d |  |
| 81 | 1.3.9.3 | Утверждение рабочего проекта | 1w | 2008-02-21 | 2008-02-27 | 80 | 0d |  |

Notes:
- 56: Используется: / Положение Минпромнауки от 30.01.02
- 62: Используется: / СНиП 1.06.04-85
- 78: Используется: / СНиП 11-01-95

| ID | WBS | Task | Duration | Start | Finish | Predecessors | Total slack | Free slack |
| --- | --- | --- | --- | --- | --- | --- | --- | --- |
| 82 | 1.3.10 | **Заказные спецификации** | 120d | 2007-06-14 | 2007-11-28 | 71 | 75d | 0d |
| 83 | 1.3.10.1 | Разработка заказных спецификаций | 3mo | 2007-06-14 | 2007-10-17 | 71 | 75d | 0d |
| 84 | 1.3.10.2 | Согласование и корректировка заказных спецификаций | 1mo | 2007-10-18 | 2007-11-28 | 83 | 75d |  |
| 85 | 1.3.11 | **Согласование рабочего проекта** | 150d | 2007-11-29 | 2008-06-25 | 79 | 685d | 0d |
| 86 | 1.3.11.1 | Подготовка утверждаемой части рабочего проекта | 1mo | 2007-11-29 | 2008-01-09 | 79 | 685d | 0d |
| 87 | 1.3.11.2 | Согласование утверждаемой части рабочего проекта | 2mo | 2008-01-10 | 2008-04-02 | 86 | 685d | 0d |
| 88 | 1.3.11.3 | Корректировка рабочего проекта | 1mo | 2008-04-03 | 2008-05-14 | 87 | 685d | 0d |
| 89 | 1.3.11.4 | Утверждение корректировок рабочего проекта | 1mo | 2008-05-15 | 2008-06-25 | 88 | 685d |  |
| 90 | 1.3.12 | **Декларация о намерениях (инвестиционный меморандум)** | 70d | 2007-06-28 | 2007-10-03 |  | 935d |  |
| 91 | 1.3.12.1 | Разработка декларации | 10d | 2007-06-28 | 2007-07-11 | 77 | 935d | 0d |
| 92 | 1.3.12.2 | Согласование декларации | 2mo | 2007-07-12 | 2007-10-03 | 91 | 935d |  |
| 93 | 1.3.13 | **Чертежи фактического исполнения (3-й этап проектирования)** | 60d | 2008-06-26 | 2008-09-17 | 85 | 685d |  |
| 94 | 1.3.13.1 | Выполнение чертежей фактического исполнения | 1mo | 2008-06-26 | 2008-08-06 | 85 | 685d | 0d |
| 95 | 1.3.13.2 | Согласование чертежей фактического исполнения | 1mo | 2008-08-07 | 2008-09-17 | 94 | 685d |  |
| 96 | 1.4 | **ФИНАНСИРОВАНИЕ ИНВЕСТПРОЕКТА** | 335d | 2006-11-30 | 2008-03-12 | 61 | 325d |  |
| 97 | 1.4.1 | Разработка проекта возможных схем финансирования инвест.проекта | 1w | 2006-11-30 | 2006-12-06 | 61 | 1150d |  |
| 98 | 1.4.2 | Проведение переговоров с банками | 2mo | 2006-11-30 | 2007-02-21 | 61 | 1095d |  |
| 99 | 1.4.3 | Проведение переговоров с компаниями по рефинансированию | 2mo | 2006-11-30 | 2007-02-21 | 61 | 1095d |  |
| 100 | 1.4.4 | Проведение переговоров со страховыми компаниями | 2mo | 2006-11-30 | 2007-02-21 | 61 | 1080d | 0d |
| 101 | 1.4.5 | Уточнение схем финансирования инвест.проекта | 1w | 2007-02-22 | 2007-02-28 | 100 | 1080d | 0d |
| 102 | 1.4.6 | Бизнесплан. 4-я инсталяция | 1w | 2007-03-01 | 2007-03-07 | 101 | 1080d | 0d |
| 103 | 1.4.7 | Принятие решения о выборе схемы финасирования инвест.проекта | 1w | 2007-03-08 | 2007-03-14 | 102 | 1080d |  |
| 104 | 1.4.8 | Подготовка документов для выполнения требований финансовых организаций | 6mo | 2006-11-30 | 2007-08-08 | 61 | 975d |  |
| 105 | 1.4.9 | Утверждение бизнесплана | 1w | 2007-03-08 | 2007-03-14 | 102 | 1080d |  |

Notes:
- 97: Используются: / Унифицированные правила и обычаи для документарных аккредитивов

| ID | WBS | Task | Type | Duration | Start | Finish | Predecessors | Total slack | Free slack |
| --- | --- | --- | --- | --- | --- | --- | --- | --- | --- |
| 106 | 1.4.10 | **Договоры на финансирование - рефинансирование инвест.проекта** |  | 10d | 2008-02-28 | 2008-03-12 | 78 | 0d |  |
| 107 | 1.4.10.1 | Разработка текста договоров |  | 1w | 2008-02-28 | 2008-03-05 | 78 | 0d |  |
| 108 | 1.4.10.2 | Подписание договоров |  | 1w | 2008-03-06 | 2008-03-12 | 107 | 0d |  |
| 109 | 1.5 | **ГЕНЕРАЛЬНЫЙ ПОДРЯД и БАЗИС ИНВЕСТИЦИОННОГО ПРОЕКТА** |  | 200d | 2005-09-30 | 2006-07-19 | 27 | 1250d |  |
| 110 | 1.5.1 | Переговоры с потенциальными ген.подрядчиками |  | 3mo | 2005-09-30 | 2006-02-08 | 27 | 1250d | 0d |
| 111 | 1.5.2 | Принятие решение о базисе инвест.проекта: "под ключ", "шефмонтаж", "авторский надзор" |  | 1mo | 2006-02-09 | 2006-03-24 | 110 | 1250d | 0d |
| 112 | 1.5.3 | Согласование суб-подрядчиков |  | 1mo | 2006-03-27 | 2006-05-10 | 111 | 1250d | 0d |
| 113 | 1.5.4 | **Генеральный контракт** |  | 50d | 2006-05-11 | 2006-07-19 | 112 | 1250d |  |
| 114 | 1.5.4.1 | Переговоры с ген.подрядчиком |  | 1mo | 2006-05-11 | 2006-06-21 | 112 | 1250d | 0d |
| 115 | 1.5.4.2 | Разработка текста генерального контракта |  | 1w | 2006-06-22 | 2006-06-28 | 114 | 1250d | 0d |
| 116 | 1.5.4.3 | Разработка приложений к генеральному контракту |  | 2w | 2006-06-29 | 2006-07-12 | 115 | 1250d | 0d |
| 117 | 1.5.4.4 | Подписание ген.контракта |  | 1w | 2006-07-13 | 2006-07-19 | 116 | 1250d |  |
| 118 | 1.6 | **ОБОРУДОВАНИЕ** |  | 910d | 2005-12-27 | 2009-07-01 | 24 | 480d |  |
| 119 | 1.6.1 | **Технико-коммерческие предложения на оборудование** |  | 121d | 2005-12-27 | 2006-06-22 | 24 | 1269d |  |
| 120 | 1.6.1.1 | Подготовка тех.заданий (опросных листов) на оборудование | milestone | 1mo | 2005-12-27 | 2006-02-08 | 24 | 1269d | 0d |
| 121 | 1.6.1.2 | Рассылка опросных листов |  | 1d | 2006-02-09 | 2006-02-09 | 120 | 1269d | 0d |
| 122 | 1.6.1.3 | Сбор и анализ Технико-коммерческиз предложений |  | 2mo | 2006-02-10 | 2006-05-11 | 121 | 1269d | 0d |
| 123 | 1.6.1.4 | Проведение тендера на оборудование |  | 1mo | 2006-05-12 | 2006-06-22 | 122 | 1269d |  |
| 124 | 1.6.2 | **Приобретение оборудования** |  | 220d | 2008-03-13 | 2009-01-14 | 82, 106 | 0d |  |
| 125 | 1.6.2.1 | Переговоры с поставщиками оборудования |  | 2mo | 2008-03-13 | 2008-06-04 | 82 | 0d |  |
| 126 | 1.6.2.2 | Разработка договоров и приложений к ним |  | 2w | 2008-06-05 | 2008-06-18 | 125 | 0d |  |
| 127 | 1.6.2.3 | Подписание договоров |  | 1mo | 2008-06-19 | 2008-07-30 | 126 | 0d |  |
| 128 | 1.6.2.4 | Оплата договоров |  | 4mo | 2008-07-31 | 2009-01-14 | 127 | 330d | 0d |
| 129 | 1.6.3 | **Доставка оборудования** |  | 240d | 2008-07-31 | 2009-07-01 | 127 | 0d |  |
| 130 | 1.6.3.1 | Переговоры с фирмами-логистиками |  | 1mo | 2008-07-31 | 2008-09-10 | 127 | 690d |  |

Notes:
- 115: Используется: / Арбитражный Регламент Европейской экономической комиссии ООН
- 125: Используются: / Инкотермс 2000, / Междун.правила поставки грузов ORGALIME SE 94

| ID | WBS | Task | Duration | Start | Finish | Predecessors | Total slack | Free slack |
| --- | --- | --- | --- | --- | --- | --- | --- | --- |
| 131 | 1.6.3.2 | **Договоры на доставку оборудования и брокерские услуги** | 10d | 2008-07-31 | 2008-08-13 |  | 0d |  |
| 132 | 1.6.3.2.1 | Разработка договоров | 1w | 2008-07-31 | 2008-08-06 | 127 | 0d |  |
| 133 | 1.6.3.2.2 | Подписание договоров | 1w | 2008-08-07 | 2008-08-13 | 132 | 0d |  |
| 134 | 1.6.3.3 | Доставка оборудования до границы | 1mo | 2009-01-15 | 2009-02-25 | 128 | 480d | 0d |
| 135 | 1.6.3.4 | Доставка оборудования от границы | 1mo | 2009-02-26 | 2009-04-08 | 134 | 480d | 0d |
| 136 | 1.6.3.5 | Растамаживание оборудования | 2mo | 2009-04-09 | 2009-07-01 | 135 | 480d |  |
| 137 | 1.6.3.6 | Организация приема грузов | 5mo | 2008-08-14 | 2009-03-11 | 133 | 0d |  |
| 138 | 1.6.3.7 | Организация складирования и охраны грузов | 5mo | 2008-08-14 | 2009-03-11 | 133 | 560d |  |
| 139 | 1.6.4 | **Разрешительная документация на имп.оборудование** | 210d | 2007-11-29 | 2008-09-17 | 82 | 685d |  |
| 140 | 1.6.4.1 | Переговоры с фирмами - "сертификаторами" | 2mo | 2007-11-29 | 2008-02-20 | 82 | 685d | 0d |
| 141 | 1.6.4.2 | Разработка договоров с "сертификаторами" и приложений к договорам | 1mo | 2008-02-21 | 2008-04-02 | 140 | 685d | 0d |
| 142 | 1.6.4.3 | Подготовка исходных документов на "сертификацию" | 1mo | 2008-04-03 | 2008-05-14 | 141 | 685d | 0d |
| 143 | 1.6.4.4 | **Получение разрешительной документации на имп.оборудование** | 90d | 2008-05-15 | 2008-09-17 | 142 | 685d |  |
| 144 | 1.6.4.4.1 | Сертификат соответствия оборудования российским стандартам | 1mo | 2008-05-15 | 2008-06-25 | 142 | 745d |  |
| 145 | 1.6.4.4.2 | Разрешение Ростехнадзора на применение в опасных производствах | 3mo | 2008-05-15 | 2008-09-17 | 142 | 685d |  |
| 146 | 1.6.4.4.3 | Лицензия на эксплуатацию оборудования | 3mo | 2008-05-15 | 2008-09-17 | 142 | 685d |  |
| 147 | 1.6.4.4.4 | Тарификация и лицензирование измерительных и контрольных приборов | 2mo | 2008-06-19 | 2008-09-10 | 126 | 690d |  |
| 148 | 1.7 | **РАБОЧАЯ ДОКУМЕНТАЦИЯ** | 270d | 2009-01-15 | 2010-01-27 | 124 | 330d |  |
| 149 | 1.7.1 | **Нормативно-техническая документация** | 180d | 2009-01-15 | 2009-09-23 | 124 | 420d |  |
| 150 | 1.7.1.1 | Разработка тех.задание на НТД | 1mo | 2009-01-15 | 2009-02-25 | 124 | 420d | 0d |
| 151 | 1.7.1.2 | Переговоры с разработчиками НТД | 1mo | 2009-02-26 | 2009-04-08 | 150 | 420d | 0d |
| 152 | 1.7.1.3 | **Разработка НТД** | 120d | 2009-04-09 | 2009-09-23 | 151 | 420d |  |
| 153 | 1.7.1.3.1 | Составление НТД | 3mo | 2009-04-09 | 2009-08-12 | 151 | 420d | 0d |
| 154 | 1.7.1.3.2 | Согласование НТД | 1mo | 2009-08-13 | 2009-09-23 | 153 | 420d |  |

Notes:
- 143: Используется: / Госгортехнадзор РД 03-485-02
- 144: Используются: / Пост-е Госстандарта от 03.05.00 / Пост-е Госстандарта от 21.09.94
- 145: Используются: / Пост-е Госгортехнадзора от 14.06.02 № 25, / Пост Правительства от 25.12.98
- 146: Используется: / ФЗ от 27.12.02

| ID | WBS | Task | Duration | Start | Finish | Predecessors | Total slack | Free slack |
| --- | --- | --- | --- | --- | --- | --- | --- | --- |
| 155 | 1.7.2 | **Исполнительная документация** | 270d | 2009-01-15 | 2010-01-27 | 124 | 330d |  |
| 156 | 1.7.2.1 | Перевод исполнительной документации на русский язык | 3mo | 2009-01-15 | 2009-05-20 | 124 | 330d | 0d |
| 157 | 1.7.2.2 | Адаптация импортной исполнительной документации к российским стандартам | 3mo | 2009-05-21 | 2009-09-23 | 156 | 330d | 0d |
| 158 | 1.7.2.3 | Разработка исполнительной документации | 3mo | 2009-09-24 | 2010-01-27 | 157 | 330d |  |
| 159 | 1.8 | **СТРОИТЕЛЬНО-МОНТАЖНЫЕ РАБОТЫ** | 575d | 2007-06-14 | 2009-08-26 | 71 | 440d |  |
| 160 | 1.8.1 | Подготовка стройплощадок | 2mo | 2007-06-14 | 2007-09-05 | 71 | 955d |  |
| 161 | 1.8.2 | **Материалы для монтажа и строительства** | 40d | 2007-11-29 | 2008-01-23 | 82 | 615d |  |
| 162 | 1.8.2.1 | Переговоры с поставщиками и перевозчиками | 1mo | 2007-11-29 | 2008-01-09 | 82 | 615d | 0d |
| 163 | 1.8.2.2 | Разработка договоров с поставщиками и перевозчиками | 1w | 2008-01-10 | 2008-01-16 | 162 | 615d | 0d |
| 164 | 1.8.2.3 | Подписание договоров | 1w | 2008-01-17 | 2008-01-23 | 163 | 615d | 0d |
| 165 | 1.8.3 | Выполнение строительных работ | 8mo | 2008-01-24 | 2008-12-24 | 164 | 615d |  |
| 166 | 1.8.4 | Монтаж оборудования | 4mo | 2009-03-12 | 2009-08-26 | 137 | 0d |  |
| 167 | 1.9 | **ОБУЧЕНИЕ ПЕРСОНАЛА** | 130d | 2009-05-21 | 2009-11-18 | 137 | 380d |  |
| 168 | 1.9.1 | Подготовка программы обучения персонала | 1mo | 2009-05-21 | 2009-07-01 | 156 | 380d | 0d |
| 169 | 1.9.2 | Проведение обучения | 3mo | 2009-07-02 | 2009-11-04 | 168 | 380d | 0d |
| 170 | 1.9.3 | Аттестация персонала, прием экзаменов | 2w | 2009-11-05 | 2009-11-18 | 169 | 380d |  |
| 171 | 1.10 | **ПУСКОНАЛАДКА И ВВОД ВЭКСПЛУАТАЦИЮ** | 240d | 2009-08-27 | 2010-07-28 | 166 | 0d |  |
| 172 | 1.10.1 | Пусконаладка оборудования и систем | 2mo | 2009-08-27 | 2009-11-18 | 166 | 50d | 0d |
| 173 | 1.10.2 | **Подключение к энергоресурсам** | 240d | 2009-08-27 | 2010-07-28 | 69 | 0d |  |
| 174 | 1.10.2.1 | Получение лимитов на энергоресурсы | 3mo | 2009-08-27 | 2009-12-30 | 69 | 0d |  |
| 175 | 1.10.2.2 | Выполнение Технических условий распорядителей энергоресурсов | 3mo | 2009-12-31 | 2010-05-05 | 174 | 0d |  |
| 176 | 1.10.2.3 | Подключение энергосистем | 2mo | 2010-05-06 | 2010-07-28 | 175 | 0d |  |
| 177 | 1.10.3 | **Проведение приемки законченным строительсвом блоков, систем, участков, установок** | 130d | 2009-11-19 | 2010-05-19 | 172 | 50d |  |
| 178 | 1.10.3.1 | Разработка приказов и состава приемочных комиссий | 5d | 2009-11-19 | 2009-11-25 | 172 | 50d | 0d |
| 179 | 1.10.3.2 | Проведение приемки | 4mo | 2009-11-26 | 2010-05-12 | 178 | 50d | 0d |
| 180 | 1.10.3.3 | Подписания локальных актов приемки | 1w | 2010-05-13 | 2010-05-19 | 179 | 50d |  |

| ID | WBS | Task | Duration | Start | Finish | Predecessors | Total slack | Free slack |
| --- | --- | --- | --- | --- | --- | --- | --- | --- |
| 181 | 1.11 | **ПРИЕМКА ЗАКОНЧЕННОГО СТРОИТЕЛЬСТВОМ ОБЪЕКТА** | 20d | 2010-07-29 | 2010-08-25 | 171 | 0d |  |
| 182 | 1.11.1 | Разработка приказа и состава приемочной комиссии | 1w | 2010-07-29 | 2010-08-04 | 171 | 0d |  |
| 183 | 1.11.2 | Проведение приемки | 2w | 2010-08-05 | 2010-08-18 | 182 | 0d |  |
| 184 | 1.11.3 | Подписания акта приемки | 1w | 2010-08-19 | 2010-08-25 | 183 | 0d |  |
| 185 | 1.12 | **ВЫВОД НА ПРОЕКТНУЮ МОЩНОСТЬ и СОГЛАСОВАНИЕ ВЫПУСКА ПРОДУКЦИИ** | 180d | 2010-08-26 | 2011-05-04 | 181 | 0d |  |
| 186 | 1.12.1 | **Завершение инвест.проекта** | 15d | 2010-08-26 | 2010-09-15 | 181 | 165d |  |
| 187 | 1.12.1.1 | Проведение работ по регламенту производственных испытаний | 1w | 2010-08-26 | 2010-09-01 | 181 | 165d | 0d |
| 188 | 1.12.1.2 | Подтверждение заданных характеристик ТЗ инвестиционнного проекта | 2d | 2010-09-02 | 2010-09-03 | 187 | 165d | 0d |
| 189 | 1.12.1.3 | Принятие решения о выполнении инвестиционного проекта | 3d | 2010-09-06 | 2010-09-08 | 188 | 165d | 0d |
| 190 | 1.12.1.4 | Проведение приемки в эксплуатацию производственного объекта | 1w | 2010-09-09 | 2010-09-15 | 189 | 165d |  |
| 191 | 1.12.2 | **Получение разрешения на выпуск продукции и контроль ее качества** | 180d | 2010-08-26 | 2011-05-04 | 181 | 0d |  |
| 192 | 1.12.2.1 | Составлении и согласовании гигиенического паспорта продукции | 3mo | 2010-08-26 | 2010-12-29 | 181 | 90d |  |
| 193 | 1.12.2.2 | Составлении и согласовании сертификата соответсвия на продукцию | 3mo | 2010-08-26 | 2010-12-29 | 181 | 90d |  |
| 194 | 1.12.2.3 | Сертификация и государственная регистрация лаборатории контроля качества | 6mo | 2010-08-26 | 2011-05-04 | 181 | 0d |  |

Notes:
- 193: Используется: / Пост-е Госстандарта № 15 от 21.09.96
